# CoastalProfilingFloat

Schedule from MS Project, 2012-01-03 to 2014-12-03.

## Calendars

- Standard: Mon-Fri 08:00-12:00, 13:00-17:00; Sat-Sun off.

## Resources

| Resource |
| --- |
| Gene |
| ME Tech |
| Machine Shop |
| EE Tech |

## Schedule

| ID | WBS | Task | Type | Duration | Start | Finish | Predecessors | Total slack | Free slack | Resources | Work |
| --- | --- | --- | --- | --- | --- | --- | --- | --- | --- | --- | --- |
| 1 | 1 | **Coastal Profiling Float Project** |  | 120d | 2012-01-03 | 2012-06-18 |  | 0d |  |  | 120h |
| 2 | 1.1 | Address permitting issues |  | 6mo | 2012-01-03 | 2012-06-18 |  | 0d |  | Gene [12.5%] | 120h |
| 3 | 2 | **System Engineering** |  | 45d | 2012-01-03 | 2012-03-05 |  | 75d | 0d |  | 64h |
| 4 | 2.1 | Science req'ts definition |  | 15d | 2012-01-03 | 2012-01-23 |  | 75d | 0d | Gene [20%] | 24h |
| 5 | 2.2 | Evaluate buoyancy engine options |  | 30d | 2012-01-24 | 2012-03-05 | 4 | 75d |  | Gene [16.7%] | 40h |
| 6 | 3 | Modeling |  | 180d | 2012-03-06 | 2012-11-12 | 3 | 536.97d |  |  |  |
| 7 | 4 | **Preliminary design** |  | 40d | 2012-06-19 | 2012-08-13 | 2, 3 | 0d |  |  | 200h |
| 8 | 4.1 | Preliminary Design |  | 40d | 2012-06-19 | 2012-08-13 |  | 0d |  | Gene [50%] | 160h |
| 9 | 4.2 | Buoyancy engine testing |  | 10d | 2012-06-19 | 2012-07-02 |  | 30d |  | ME Tech [50%] | 40h |
| 10 | 5 | PDR | milestone | 0d | 2012-08-13 | 2012-08-13 | 7 | 0d |  |  |  |
| 11 | 6 | Final Design |  | 60d | 2012-08-14 | 2012-11-05 | 10 | 0d |  | Gene [50%] | 240h |
| 12 | 7 | CDR | milestone | 0d | 2012-11-05 | 2012-11-05 | 11 | 0d |  |  |  |
| 13 | 8 | Modify first float |  | 6.06w | 2012-11-06 | 2012-12-18 | 12 | 0d |  | Machine Shop [33%] | 80h |
| 14 | 9 | **Engr Deployment #1** |  | 20d | 2012-12-18 | 2013-01-15 | 13 | 0d |  |  | 216h |
| 15 | 9.1 | Engr Deployment #1 ME |  | 20d | 2012-12-18 | 2013-01-15 |  | 0d |  | Gene [58.2%] | 88h |
| 16 | 9.2 | Engr Deployment #1 ME Tech |  | 15d | 2012-12-18 | 2013-01-08 |  | 5d |  | ME Tech [41.3%] | 48h |
| 17 | 9.3 | Engr Deployment #1 EE Tech |  | 20d | 2012-12-18 | 2013-01-15 |  | 0d |  | EE Tech [50%] | 80h |
| 18 | 10 | **Engr Refine - Redeploy** |  | 266.67d | 2013-01-15 | 2014-01-22 | 14 | 0d |  |  | 400h |
| 19 | 10.1 | Engr R-R ME |  | 266.67d | 2013-01-15 | 2014-01-22 |  | 0d |  | Gene [15%] | 320h |
| 20 | 10.2 | Engr R-R ME Tech |  | 60d | 2013-01-15 | 2013-04-09 |  | 206.67d |  | ME Tech [16.7%] | 80h |
| 21 | 11 | Science Deployment #1 |  | 25d | 2014-01-22 | 2014-02-26 | 18 | 0d |  | Gene [46.7%] | 88h |
| 22 | 12 | **Sci Refine - Redeploy** |  | 200d | 2014-02-26 | 2014-12-03 | 21 | 0d |  |  | 400h |
| 23 | 12.1 | Sci R-R ME |  | 200d | 2014-02-26 | 2014-12-03 |  | 0d |  | Gene [20%] | 320h |
| 24 | 12.2 | Sci R-R ME Tech |  | 60d | 2014-02-26 | 2014-05-21 |  | 140d |  | ME Tech [16.7%] | 80h |
| 25 | 13 | Technology transfer discussions |  | 10mo | 2014-01-22 | 2014-10-29 | 18 | 25d |  | Gene [5%] | 80h |
